# Sample Building Project 01

How a schedule from MS Project changed from version to version. A marks actual dates.

## Version 1 (saved 2020-12-17, file Sample Building Time Schedule 04.mpp)

| ID | WBS | Task | Duration | Start | Finish | Predecessors | Total float |
| --- | --- | --- | --- | --- | --- | --- | --- |
| 1 | 1 | **پروژه ساختماني نمونه** | 149d | 2018-09-22 | 2019-03-13 |  | 0d |
| 2 |  | آغاز پروژه | 0d | 2018-09-22 | 2018-09-22 |  | 0d |
| 3 | 1.2 | **تجهيز کارگاه** | 135d | 2018-09-22 | 2019-02-25 |  | 0d |
| 4 |  | تجهيز کارگاه اوليه | 25d | 2018-09-22 | 2018-10-20 | 2 | 0d |
| 5 |  | تجهيز کارگاه در طول پروژه | 110d | 2018-10-21 | 2019-02-25 | 4 | 2d |
| 6 | 1.3 | **خاکبرداري** | 4d | 2018-10-21 | 2018-10-24 |  | 0d |
| 7 |  | گودبرداري با ماشين | 2d | 2018-10-21 | 2018-10-22 | 4 | 0d |
| 8 |  | خاکبرداري دستي و رگلاژ کف | 2d | 2018-10-23 | 2018-10-24 | 7 | 0d |
| 9 | 1.4 | **فونداسيون** | 16d | 2018-10-25 | 2018-11-12 |  | 0d |
| 10 |  | اجراي بتن مگر | 3d | 2018-10-25 | 2018-10-28 | 8 | 0d |
| 11 |  | آرماتور فونداسيون | 7d | 2018-10-29 | 2018-11-05 | 10 | 0d |
| 12 |  | قالب بندي فونداسيون | 5d | 2018-11-06 | 2018-11-11 | 11 | 0d |
| 13 |  | بتن ريزي فونداسيون | 1d | 2018-11-12 | 2018-11-12 | 12 | 0d |
| 14 | 1.5 | **اسکلت** | 49d | 2018-10-21 | 2018-12-16 |  | 0d |
| 15 |  | اجراي شابلون و گروت ريزي | 2d | 2018-11-13 | 2018-11-14 | 13 | 0d |
| 16 |  | اجراي بيس پليت ستونها | 3d | 2018-11-15 | 2018-11-18 | 15 | 0d |
| 17 |  | ساخت ستون | 10d | 2018-10-21 | 2018-10-31 | 4 | 3d |
| 18 |  | ساخت تير | 15d | 2018-11-01 | 2018-11-18 | 17 | 3d |
| 19 |  | ساخت بادبند و پله | 5d | 2018-11-19 | 2018-11-24 | 18 | 6d |
| 20 |  | نصب ستون | 3d | 2018-11-19 | 2018-11-21 | 17, 16 | 0d |
| 21 |  | نصب تيرهاي حمال | 8d | 2018-11-22 | 2018-12-01 | 18, 20 | 0d |
| 22 |  | نصب بادبند | 3d | 2018-12-02 | 2018-12-04 | 19, 21 | 0d |
| 23 |  | نصب تير پله | 2d | 2018-12-02 | 2018-12-03 | 19, 21 | 1d |
| 24 |  | اتصالات،جوشکاري و ضد زنگ | 10d | 2018-12-05 | 2018-12-16 | 20, 21, 22, 23 | 0d |
| 25 | 1.6 | **سقف سازي** | 44d | 2018-11-13 | 2019-01-02 |  | 19d |
| 26 |  | ساخت تيرچه هاي فلزي | 10d | 2018-11-13 | 2018-11-24 | 13 | 19d |
| 27 |  | اجراي سقف همکف | 4d | 2018-12-17 | 2018-12-20 | 26, 24 | 0d |
| 28 |  | اجراي سقف اول | 4d | 2018-12-22 | 2018-12-25 | 27 | 0d |
| 29 |  | اجراي سقف دوم | 4d | 2018-12-26 | 2018-12-30 | 28 | 0d |
| 30 |  | اجراي کنسولها و پله | 3d | 2018-12-31 | 2019-01-02 | 29 | 20d |
| 31 | 1.7 | **سفت کاري** | 28d | 2018-12-17 | 2019-01-17 |  | 17d |
| 32 |  | خاکريزي پي و پشت ديوارها | 3d | 2018-12-17 | 2018-12-19 | 24 | 17d |
| 33 |  | اجراي ديوار چيني | 15d | 2018-12-20 | 2019-01-06 | 32 | 17d |
| 34 |  | ساخت و نصب نعل درگاه ها | 4d | 2019-01-07 | 2019-01-10 | 30, 33 | 17d |
| 35 |  | چهارچوب،فريم پنجره ها | 6d | 2019-01-12 | 2019-01-17 | 34 | 17d |
| 36 | 1.8 | **تاسيسات فاز اول** | 13d | 2018-12-31 | 2019-01-14 |  | 0d |
| 37 |  | اجراي لوله هاي فاضلاب و آب باران | 4d | 2018-12-31 | 2019-01-03 | 29 | 31d |
| 38 |  | اجراي لوله کشي سرد و گرم | 8d | 2019-01-05 | 2019-01-13 | 37 | 31d |
| 39 |  | اجراي کانالهاي هوا | 12d | 2018-12-31 | 2019-01-13 | 29 | 33d |
| 40 |  | اجراي لوله هاي برق | 8d | 2018-12-31 | 2019-01-08 | 29 | 0d |
| 41 |  | نصب ساپورتهاي تاسيساتي | 5d | 2019-01-09 | 2019-01-14 | 40 | 0d |
| 42 | 1.9 | **کف سازي** | 7d | 2019-01-15 | 2019-01-22 |  | 14d |
| 43 |  | اجراي پوکه سرويس ها | 4d | 2019-01-15 | 2019-01-19 | 41 | 17d |
| 44 |  | اجراي پوکه طبقات | 6d | 2019-01-15 | 2019-01-21 | 41 | 44d |
| 45 |  | شيب بندي و پوکه ريزي بام | 2d | 2019-01-15 | 2019-01-16 | 41 | 14d |
| 46 |  | عايقکاري سرويس ها | 3d | 2019-01-20 | 2019-01-22 | 43 | 17d |
| 47 |  | عايق کاري بام | 2d | 2019-01-17 | 2019-01-19 | 45 | 14d |
| 48 | 1.10 | **سقف کاذب** | 12d | 2019-01-15 | 2019-01-28 |  | 22d |
| 49 |  | زير سازي سقف کاذب | 8d | 2019-01-15 | 2019-01-23 | 41 | 22d |
| 50 |  | نصب صفحات رابيتس | 4d | 2019-01-24 | 2019-01-28 | 49 | 22d |
| 51 | 1.11 | **نازک کاري** | 32d | 2019-01-15 | 2019-02-20 |  | 0d |
| 52 |  | گچ و خاک ديوارها | 16d | 2019-01-15 | 2019-02-02 | 41 | 0d |
| 53 |  | سيمانکاري آستر | 10d | 2019-01-15 | 2019-01-26 | 41 | 6d |
| 54 |  | سفيدکاري | 10d | 2019-02-03 | 2019-02-13 | 52, 53, 50 | 18d |
| 55 |  | رويه تخته ماله اي | 6d | 2019-02-14 | 2019-02-20 | 57, 54 | 18d |
| 56 |  | سنگ کف | 11d | 2019-01-15 | 2019-01-27 | 41 | 5d |
| 57 |  | سنگ قرنيز ديوارها | 4d | 2019-02-03 | 2019-02-06 | 52, 53, 56 | 0d |
| 58 |  | موزاييک | 3d | 2019-01-20 | 2019-01-22 | 47 | 25d |
| 59 |  | نصب سنگ پله | 3d | 2019-01-28 | 2019-01-30 | 56 | 6d |
| 60 |  | در و پنجره و نرده ها | 8d | 2019-02-07 | 2019-02-16 | 57, 56, 35 | 7d |
| 61 |  | درب و کمد چوبي | 8d | 2019-02-07 | 2019-02-16 | 57, 35, 56 | 0d |
| 62 | 1.12 | **نماسازي** | 26d | 2019-01-20 | 2019-02-18 |  | 8d |
| 63 |  | اجراي ازاره سنگي نما | 2d | 2019-01-20 | 2019-01-21 | 47 | 14d |
| 64 |  | اجراي سنگ نما | 16d | 2019-01-22 | 2019-02-09 | 63 | 14d |
| 65 |  | نصب شيشه ها | 2d | 2019-02-17 | 2019-02-18 | 60, 64 | 8d |
| 66 | 1.13 | **کاشي و سراميک** | 12d | 2019-01-28 | 2019-02-10 |  | 13d |
| 67 |  | کاشي کاري سرويسها | 6d | 2019-01-28 | 2019-02-03 | 56, 46 | 13d |
| 68 |  | نصب توالت هاي شرقي | 2d | 2019-02-04 | 2019-02-05 | 67 | 13d |
| 69 |  | نصب سراميک سرويسها | 4d | 2019-02-06 | 2019-02-10 | 68 | 13d |
| 70 | 1.14 | **تاسيسات فاز دوم** | 38d | 2019-01-15 | 2019-02-27 |  | 0d |

| ID | WBS | Task | Duration | Start | Finish | Predecessors | Total float |
| --- | --- | --- | --- | --- | --- | --- | --- |
| 71 |  | ساخت و نصب دريچه ها | 4d | 2019-02-07 | 2019-02-11 | 38, 56, 57 | 10d |
| 72 |  | نصب دستگاه چيلر | 2d | 2019-01-23 | 2019-01-24 | 58, 39 | 25d |
| 73 |  | سيم کشي و کابل کشي | 8d | 2019-02-03 | 2019-02-11 | 52 | 9d |
| 74 |  | نصب کليد و پريز و ساير اقلام برقي | 4d | 2019-02-10 | 2019-02-13 | 84 | 6d |
| 75 |  | نصب چراغها | 1d | 2019-02-21 | 2019-02-21 | 86, 74 | 0d |
| 76 |  | ساخت و نصب تابلوهاي برق | 5d | 2019-02-23 | 2019-02-27 | 73, 75 | 0d |
| 77 |  | نصب سرويس هاي بهداشتي و شيرآلات | 2d | 2019-02-11 | 2019-02-12 | 69, 38 | 13d |
| 78 |  | نصب آسانسور | 30d | 2019-01-15 | 2019-02-18 | 41 | 8d |
| 79 | 1.15 | **موتورخانه** | 28d | 2019-01-15 | 2019-02-16 |  | 10d |
| 80 |  | اجراي لوله کشي موتورخانه | 3d | 2019-01-15 | 2019-01-17 | 41 | 29d |
| 81 |  | نصب ديگها و مشعل پمپها | 2d | 2019-01-19 | 2019-01-20 | 80 | 29d |
| 82 |  | تست و راه اندازي و عايق کاري موتورخانه | 4d | 2019-02-12 | 2019-02-16 | 72, 71, 81 | 10d |
| 83 | 1.16 | **نقاشي** | 18d | 2019-01-31 | 2019-02-20 |  | 6d |
| 84 |  | اجراي کامل نقاشي سطوح گچي | 8d | 2019-01-31 | 2019-02-09 | 59 | 6d |
| 85 |  | اجراي کامل نقاشي سطوح فلزي | 3d | 2019-02-17 | 2019-02-19 | 60 | 7d |
| 86 |  | اجراي کامل نقاشي سطوح چوبي | 4d | 2019-02-17 | 2019-02-20 | 61 | 0d |
| 87 | 1.17 | **تميز کاري و تحويل و برچيدن کارگاه** | 12d | 2019-02-28 | 2019-03-13 |  | 0d |
| 88 |  | تميز کاري و تحويل و برچيدن کارگاه | 12d | 2019-02-28 | 2019-03-13 | 86, 82, 76, 65, 77, 85, 5, 78 | 0d |
| 89 |  | پايان پروژه | 0d | 2019-03-13 | 2019-03-13 | 88 | 0d |

## Version 2 (saved 2020-12-17, file Sample Building Time Schedule 05.mpp)

Last finish 2019-03-13 → 2019-03-14 (+1d).

Changed:

| ID | Task | Start | Finish |
| --- | --- | --- | --- |
| 1 | **پروژه ساختماني نمونه** | 2018-09-22 → 2018-09-23 (+1d) | 2019-03-13 → 2019-03-14 (+1d) |
| 2 | آغاز پروژه | 2018-09-22 → 2018-09-23 (+1d) | 2018-09-22 → 2018-09-23 (+1d) |
| 3 | **تجهيز کارگاه** | 2018-09-22 → 2018-09-23 (+1d) | 2019-02-25 → 2019-02-26 (+1d) |
| 4 | تجهيز کارگاه اوليه | 2018-09-22 → 2018-09-23 (+1d) | 2018-10-20 → 2018-10-21 (+1d) |
| 5 | تجهيز کارگاه در طول پروژه | 2018-10-21 → 2018-10-22 (+1d) | 2019-02-25 → 2019-02-26 (+1d) |
| 6 | **خاکبرداري** | 2018-10-21 → 2018-10-22 (+1d) | 2018-10-24 → 2018-10-25 (+1d) |
| 7 | گودبرداري با ماشين | 2018-10-21 → 2018-10-22 (+1d) | 2018-10-22 → 2018-10-23 (+1d) |
| 8 | خاکبرداري دستي و رگلاژ کف | 2018-10-23 → 2018-10-24 (+1d) | 2018-10-24 → 2018-10-25 (+1d) |
| 9 | **فونداسيون** | 2018-10-25 → 2018-10-27 (+2d) | 2018-11-12 → 2018-11-13 (+1d) |
| 10 | اجراي بتن مگر | 2018-10-25 → 2018-10-27 (+2d) | 2018-10-28 → 2018-10-29 (+1d) |
| 11 | آرماتور فونداسيون | 2018-10-29 → 2018-10-30 (+1d) | 2018-11-05 → 2018-11-06 (+1d) |
| 12 | قالب بندي فونداسيون | 2018-11-06 → 2018-11-07 (+1d) | 2018-11-11 → 2018-11-12 (+1d) |
| 13 | بتن ريزي فونداسيون | 2018-11-12 → 2018-11-13 (+1d) | 2018-11-12 → 2018-11-13 (+1d) |
| 14 | **اسکلت** | 2018-10-21 → 2018-10-22 (+1d) | 2018-12-16 → 2018-12-17 (+1d) |
| 15 | اجراي شابلون و گروت ريزي | 2018-11-13 → 2018-11-14 (+1d) | 2018-11-14 → 2018-11-15 (+1d) |
| 16 | اجراي بيس پليت ستونها | 2018-11-15 → 2018-11-17 (+2d) | 2018-11-18 → 2018-11-19 (+1d) |
| 17 | ساخت ستون | 2018-10-21 → 2018-10-22 (+1d) | 2018-10-31 → 2018-11-01 (+1d) |
| 18 | ساخت تير | 2018-11-01 → 2018-11-03 (+2d) | 2018-11-18 → 2018-11-19 (+1d) |
| 19 | ساخت بادبند و پله | 2018-11-19 → 2018-11-20 (+1d) | 2018-11-24 → 2018-11-25 (+1d) |
| 20 | نصب ستون | 2018-11-19 → 2018-11-20 (+1d) | 2018-11-21 → 2018-11-22 (+1d) |
| 21 | نصب تيرهاي حمال | 2018-11-22 → 2018-11-24 (+2d) | 2018-12-01 → 2018-12-02 (+1d) |
| 22 | نصب بادبند | 2018-12-02 → 2018-12-03 (+1d) | 2018-12-04 → 2018-12-05 (+1d) |
| 23 | نصب تير پله | 2018-12-02 → 2018-12-03 (+1d) | 2018-12-03 → 2018-12-04 (+1d) |
| 24 | اتصالات،جوشکاري و ضد زنگ | 2018-12-05 → 2018-12-06 (+1d) | 2018-12-16 → 2018-12-17 (+1d) |
| 25 | **سقف سازي** | 2018-11-13 → 2018-11-14 (+1d) | 2019-01-02 → 2019-01-03 (+1d) |
| 26 | ساخت تيرچه هاي فلزي | 2018-11-13 → 2018-11-14 (+1d) | 2018-11-24 → 2018-11-25 (+1d) |
| 27 | اجراي سقف همکف | 2018-12-17 → 2018-12-18 (+1d) | 2018-12-20 → 2018-12-22 (+2d) |
| 28 | اجراي سقف اول | 2018-12-22 → 2018-12-23 (+1d) | 2018-12-25 → 2018-12-26 (+1d) |
| 29 | اجراي سقف دوم | 2018-12-26 → 2018-12-27 (+1d) | 2018-12-30 → 2018-12-31 (+1d) |
| 30 | اجراي کنسولها و پله | 2018-12-31 → 2019-01-01 (+1d) | 2019-01-02 → 2019-01-03 (+1d) |
| 31 | **سفت کاري** | 2018-12-17 → 2018-12-18 (+1d) | 2019-01-17 → 2019-01-19 (+2d) |
| 32 | خاکريزي پي و پشت ديوارها | 2018-12-17 → 2018-12-18 (+1d) | 2018-12-19 → 2018-12-20 (+1d) |
| 33 | اجراي ديوار چيني | 2018-12-20 → 2018-12-22 (+2d) | 2019-01-06 → 2019-01-07 (+1d) |
| 34 | ساخت و نصب نعل درگاه ها | 2019-01-07 → 2019-01-08 (+1d) | 2019-01-10 → 2019-01-12 (+2d) |
| 35 | چهارچوب،فريم پنجره ها | 2019-01-12 → 2019-01-13 (+1d) | 2019-01-17 → 2019-01-19 (+2d) |
| 36 | **تاسيسات فاز اول** | 2018-12-31 → 2019-01-01 (+1d) | 2019-01-14 → 2019-01-15 (+1d) |
| 37 | اجراي لوله هاي فاضلاب و آب باران | 2018-12-31 → 2019-01-01 (+1d) | 2019-01-03 → 2019-01-05 (+2d) |
| 38 | اجراي لوله کشي سرد و گرم | 2019-01-05 → 2019-01-06 (+1d) | 2019-01-13 → 2019-01-14 (+1d) |
| 39 | اجراي کانالهاي هوا | 2018-12-31 → 2019-01-01 (+1d) | 2019-01-13 → 2019-01-14 (+1d) |
| 40 | اجراي لوله هاي برق | 2018-12-31 → 2019-01-01 (+1d) | 2019-01-08 → 2019-01-09 (+1d) |
| 41 | نصب ساپورتهاي تاسيساتي | 2019-01-09 → 2019-01-10 (+1d) | 2019-01-14 → 2019-01-15 (+1d) |
| 42 | **کف سازي** | 2019-01-15 → 2019-01-16 (+1d) | 2019-01-22 → 2019-01-23 (+1d) |
| 43 | اجراي پوکه سرويس ها | 2019-01-15 → 2019-01-16 (+1d) | 2019-01-19 → 2019-01-20 (+1d) |
| 44 | اجراي پوکه طبقات | 2019-01-15 → 2019-01-16 (+1d) | 2019-01-21 → 2019-01-22 (+1d) |
| 45 | شيب بندي و پوکه ريزي بام | 2019-01-15 → 2019-01-16 (+1d) | 2019-01-16 → 2019-01-17 (+1d) |
| 46 | عايقکاري سرويس ها | 2019-01-20 → 2019-01-21 (+1d) | 2019-01-22 → 2019-01-23 (+1d) |
| 47 | عايق کاري بام | 2019-01-17 → 2019-01-19 (+2d) | 2019-01-19 → 2019-01-20 (+1d) |
| 48 | **سقف کاذب** | 2019-01-15 → 2019-01-16 (+1d) | 2019-01-28 → 2019-01-29 (+1d) |
| 49 | زير سازي سقف کاذب | 2019-01-15 → 2019-01-16 (+1d) | 2019-01-23 → 2019-01-24 (+1d) |
| 50 | نصب صفحات رابيتس | 2019-01-24 → 2019-01-26 (+2d) | 2019-01-28 → 2019-01-29 (+1d) |
| 51 | **نازک کاري** | 2019-01-15 → 2019-01-16 (+1d) | 2019-02-20 → 2019-02-21 (+1d) |
| 52 | گچ و خاک ديوارها | 2019-01-15 → 2019-01-16 (+1d) | 2019-02-02 → 2019-02-03 (+1d) |
| 53 | سيمانکاري آستر | 2019-01-15 → 2019-01-16 (+1d) | 2019-01-26 → 2019-01-27 (+1d) |
| 54 | سفيدکاري | 2019-02-03 → 2019-02-04 (+1d) | 2019-02-13 → 2019-02-14 (+1d) |
| 55 | رويه تخته ماله اي | 2019-02-14 → 2019-02-16 (+2d) | 2019-02-20 → 2019-02-21 (+1d) |
| 56 | سنگ کف | 2019-01-15 → 2019-01-16 (+1d) | 2019-01-27 → 2019-01-28 (+1d) |
| 57 | سنگ قرنيز ديوارها | 2019-02-03 → 2019-02-04 (+1d) | 2019-02-06 → 2019-02-07 (+1d) |
| 58 | موزاييک | 2019-01-20 → 2019-01-21 (+1d) | 2019-01-22 → 2019-01-23 (+1d) |
| 59 | نصب سنگ پله | 2019-01-28 → 2019-01-29 (+1d) | 2019-01-30 → 2019-01-31 (+1d) |
| 60 | در و پنجره و نرده ها | 2019-02-07 → 2019-02-09 (+2d) | 2019-02-16 → 2019-02-17 (+1d) |
| 61 | درب و کمد چوبي | 2019-02-07 → 2019-02-09 (+2d) | 2019-02-16 → 2019-02-17 (+1d) |
| 62 | **نماسازي** | 2019-01-20 → 2019-01-21 (+1d) | 2019-02-18 → 2019-02-19 (+1d) |
| 63 | اجراي ازاره سنگي نما | 2019-01-20 → 2019-01-21 (+1d) | 2019-01-21 → 2019-01-22 (+1d) |
| 64 | اجراي سنگ نما | 2019-01-22 → 2019-01-23 (+1d) | 2019-02-09 → 2019-02-10 (+1d) |
| 65 | نصب شيشه ها | 2019-02-17 → 2019-02-18 (+1d) | 2019-02-18 → 2019-02-19 (+1d) |
| 66 | **کاشي و سراميک** | 2019-01-28 → 2019-01-29 (+1d) | 2019-02-10 → 2019-02-11 (+1d) |
| 67 | کاشي کاري سرويسها | 2019-01-28 → 2019-01-29 (+1d) | 2019-02-03 → 2019-02-04 (+1d) |
| 68 | نصب توالت هاي شرقي | 2019-02-04 → 2019-02-05 (+1d) | 2019-02-05 → 2019-02-06 (+1d) |
| 69 | نصب سراميک سرويسها | 2019-02-06 → 2019-02-07 (+1d) | 2019-02-10 → 2019-02-11 (+1d) |
| 70 | **تاسيسات فاز دوم** | 2019-01-15 → 2019-01-16 (+1d) | 2019-02-27 → 2019-02-28 (+1d) |

| ID | Task | Start | Finish |
| --- | --- | --- | --- |
| 71 | ساخت و نصب دريچه ها | 2019-02-07 → 2019-02-09 (+2d) | 2019-02-11 → 2019-02-12 (+1d) |
| 72 | نصب دستگاه چيلر | 2019-01-23 → 2019-01-24 (+1d) | 2019-01-24 → 2019-01-26 (+2d) |
| 73 | سيم کشي و کابل کشي | 2019-02-03 → 2019-02-04 (+1d) | 2019-02-11 → 2019-02-12 (+1d) |
| 74 | نصب کليد و پريز و ساير اقلام برقي | 2019-02-10 → 2019-02-11 (+1d) | 2019-02-13 → 2019-02-14 (+1d) |
| 75 | نصب چراغها | 2019-02-21 → 2019-02-23 (+2d) | 2019-02-21 → 2019-02-23 (+2d) |
| 76 | ساخت و نصب تابلوهاي برق | 2019-02-23 → 2019-02-24 (+1d) | 2019-02-27 → 2019-02-28 (+1d) |
| 77 | نصب سرويس هاي بهداشتي و شيرآلات | 2019-02-11 → 2019-02-12 (+1d) | 2019-02-12 → 2019-02-13 (+1d) |
| 78 | نصب آسانسور | 2019-01-15 → 2019-01-16 (+1d) | 2019-02-18 → 2019-02-19 (+1d) |
| 79 | **موتورخانه** | 2019-01-15 → 2019-01-16 (+1d) | 2019-02-16 → 2019-02-17 (+1d) |
| 80 | اجراي لوله کشي موتورخانه | 2019-01-15 → 2019-01-16 (+1d) | 2019-01-17 → 2019-01-19 (+2d) |
| 81 | نصب ديگها و مشعل پمپها | 2019-01-19 → 2019-01-20 (+1d) | 2019-01-20 → 2019-01-21 (+1d) |
| 82 | تست و راه اندازي و عايق کاري موتورخانه | 2019-02-12 → 2019-02-13 (+1d) | 2019-02-16 → 2019-02-17 (+1d) |
| 83 | **نقاشي** | 2019-01-31 → 2019-02-02 (+2d) | 2019-02-20 → 2019-02-21 (+1d) |
| 84 | اجراي کامل نقاشي سطوح گچي | 2019-01-31 → 2019-02-02 (+2d) | 2019-02-09 → 2019-02-10 (+1d) |
| 85 | اجراي کامل نقاشي سطوح فلزي | 2019-02-17 → 2019-02-18 (+1d) | 2019-02-19 → 2019-02-20 (+1d) |
| 86 | اجراي کامل نقاشي سطوح چوبي | 2019-02-17 → 2019-02-18 (+1d) | 2019-02-20 → 2019-02-21 (+1d) |
| 87 | **تميز کاري و تحويل و برچيدن کارگاه** | 2019-02-28 → 2019-03-02 (+2d) | 2019-03-13 → 2019-03-14 (+1d) |
| 88 | تميز کاري و تحويل و برچيدن کارگاه | 2019-02-28 → 2019-03-02 (+2d) | 2019-03-13 → 2019-03-14 (+1d) |
| 89 | پايان پروژه | 2019-03-13 → 2019-03-14 (+1d) | 2019-03-13 → 2019-03-14 (+1d) |

## Version 3 (data date 2018-11-23, saved 2021-02-10, file Sample Building Time Schedule 07.mpp)

Last finish stays 2019-03-14.

Changed:

| ID | Task | Other |
| --- | --- | --- |
| 1 | **پروژه ساختماني نمونه** | baseline start none → 2018-09-23; baseline finish none → 2019-03-14 |
| 2 | آغاز پروژه | baseline start none → 2018-09-23; baseline finish none → 2018-09-23 |
| 3 | **تجهيز کارگاه** | baseline start none → 2018-09-23; baseline finish none → 2019-02-26 |
| 4 | تجهيز کارگاه اوليه | baseline start none → 2018-09-23; baseline finish none → 2018-10-21 |
| 5 | تجهيز کارگاه در طول پروژه | baseline start none → 2018-10-22; baseline finish none → 2019-02-26 |
| 6 | **خاکبرداري** | baseline start none → 2018-10-22; baseline finish none → 2018-10-25 |
| 7 | گودبرداري با ماشين | baseline start none → 2018-10-22; baseline finish none → 2018-10-23 |
| 8 | خاکبرداري دستي و رگلاژ کف | baseline start none → 2018-10-24; baseline finish none → 2018-10-25 |
| 9 | **فونداسيون** | baseline start none → 2018-10-27; baseline finish none → 2018-11-13 |
| 10 | اجراي بتن مگر | baseline start none → 2018-10-27; baseline finish none → 2018-10-29 |
| 11 | آرماتور فونداسيون | baseline start none → 2018-10-30; baseline finish none → 2018-11-06 |
| 12 | قالب بندي فونداسيون | baseline start none → 2018-11-07; baseline finish none → 2018-11-12 |
| 13 | بتن ريزي فونداسيون | baseline start none → 2018-11-13; baseline finish none → 2018-11-13 |
| 14 | **اسکلت** | baseline start none → 2018-10-22; baseline finish none → 2018-12-17 |
| 15 | اجراي شابلون و گروت ريزي | baseline start none → 2018-11-14; baseline finish none → 2018-11-15 |
| 16 | اجراي بيس پليت ستونها | baseline start none → 2018-11-17; baseline finish none → 2018-11-19 |
| 17 | ساخت ستون | baseline start none → 2018-10-22; baseline finish none → 2018-11-01 |
| 18 | ساخت تير | baseline start none → 2018-11-03; baseline finish none → 2018-11-19 |
| 19 | ساخت بادبند و پله | baseline start none → 2018-11-20; baseline finish none → 2018-11-25 |
| 20 | نصب ستون | baseline start none → 2018-11-20; baseline finish none → 2018-11-22 |
| 21 | نصب تيرهاي حمال | baseline start none → 2018-11-24; baseline finish none → 2018-12-02 |
| 22 | نصب بادبند | baseline start none → 2018-12-03; baseline finish none → 2018-12-05 |
| 23 | نصب تير پله | baseline start none → 2018-12-03; baseline finish none → 2018-12-04 |
| 24 | اتصالات،جوشکاري و ضد زنگ | baseline start none → 2018-12-06; baseline finish none → 2018-12-17 |
| 25 | **سقف سازي** | baseline start none → 2018-11-14; baseline finish none → 2019-01-03 |
| 26 | ساخت تيرچه هاي فلزي | baseline start none → 2018-11-14; baseline finish none → 2018-11-25 |
| 27 | اجراي سقف همکف | baseline start none → 2018-12-18; baseline finish none → 2018-12-22 |
| 28 | اجراي سقف اول | baseline start none → 2018-12-23; baseline finish none → 2018-12-26 |
| 29 | اجراي سقف دوم | baseline start none → 2018-12-27; baseline finish none → 2018-12-31 |
| 30 | اجراي کنسولها و پله | baseline start none → 2019-01-01; baseline finish none → 2019-01-03 |
| 31 | **سفت کاري** | baseline start none → 2018-12-18; baseline finish none → 2019-01-19 |
| 32 | خاکريزي پي و پشت ديوارها | baseline start none → 2018-12-18; baseline finish none → 2018-12-20 |
| 33 | اجراي ديوار چيني | baseline start none → 2018-12-22; baseline finish none → 2019-01-07 |
| 34 | ساخت و نصب نعل درگاه ها | baseline start none → 2019-01-08; baseline finish none → 2019-01-12 |
| 35 | چهارچوب،فريم پنجره ها | baseline start none → 2019-01-13; baseline finish none → 2019-01-19 |
| 36 | **تاسيسات فاز اول** | baseline start none → 2019-01-01; baseline finish none → 2019-01-15 |
| 37 | اجراي لوله هاي فاضلاب و آب باران | baseline start none → 2019-01-01; baseline finish none → 2019-01-05 |
| 38 | اجراي لوله کشي سرد و گرم | baseline start none → 2019-01-06; baseline finish none → 2019-01-14 |
| 39 | اجراي کانالهاي هوا | baseline start none → 2019-01-01; baseline finish none → 2019-01-14 |
| 40 | اجراي لوله هاي برق | baseline start none → 2019-01-01; baseline finish none → 2019-01-09 |
| 41 | نصب ساپورتهاي تاسيساتي | baseline start none → 2019-01-10; baseline finish none → 2019-01-15 |
| 42 | **کف سازي** | baseline start none → 2019-01-16; baseline finish none → 2019-01-23 |
| 43 | اجراي پوکه سرويس ها | baseline start none → 2019-01-16; baseline finish none → 2019-01-20 |
| 44 | اجراي پوکه طبقات | baseline start none → 2019-01-16; baseline finish none → 2019-01-22 |
| 45 | شيب بندي و پوکه ريزي بام | baseline start none → 2019-01-16; baseline finish none → 2019-01-17 |
| 46 | عايقکاري سرويس ها | baseline start none → 2019-01-21; baseline finish none → 2019-01-23 |
| 47 | عايق کاري بام | baseline start none → 2019-01-19; baseline finish none → 2019-01-20 |
| 48 | **سقف کاذب** | baseline start none → 2019-01-16; baseline finish none → 2019-01-29 |
| 49 | زير سازي سقف کاذب | baseline start none → 2019-01-16; baseline finish none → 2019-01-24 |
| 50 | نصب صفحات رابيتس | baseline start none → 2019-01-26; baseline finish none → 2019-01-29 |
| 51 | **نازک کاري** | baseline start none → 2019-01-16; baseline finish none → 2019-02-21 |
| 52 | گچ و خاک ديوارها | baseline start none → 2019-01-16; baseline finish none → 2019-02-03 |
| 53 | سيمانکاري آستر | baseline start none → 2019-01-16; baseline finish none → 2019-01-27 |
| 54 | سفيدکاري | baseline start none → 2019-02-04; baseline finish none → 2019-02-14 |
| 55 | رويه تخته ماله اي | baseline start none → 2019-02-16; baseline finish none → 2019-02-21 |
| 56 | سنگ کف | baseline start none → 2019-01-16; baseline finish none → 2019-01-28 |
| 57 | سنگ قرنيز ديوارها | baseline start none → 2019-02-04; baseline finish none → 2019-02-07 |
| 58 | موزاييک | baseline start none → 2019-01-21; baseline finish none → 2019-01-23 |
| 59 | نصب سنگ پله | baseline start none → 2019-01-29; baseline finish none → 2019-01-31 |
| 60 | در و پنجره و نرده ها | baseline start none → 2019-02-09; baseline finish none → 2019-02-17 |
| 61 | درب و کمد چوبي | baseline start none → 2019-02-09; baseline finish none → 2019-02-17 |
| 62 | **نماسازي** | baseline start none → 2019-01-21; baseline finish none → 2019-02-19 |
| 63 | اجراي ازاره سنگي نما | baseline start none → 2019-01-21; baseline finish none → 2019-01-22 |
| 64 | اجراي سنگ نما | baseline start none → 2019-01-23; baseline finish none → 2019-02-10 |
| 65 | نصب شيشه ها | baseline start none → 2019-02-18; baseline finish none → 2019-02-19 |
| 66 | **کاشي و سراميک** | baseline start none → 2019-01-29; baseline finish none → 2019-02-11 |
| 67 | کاشي کاري سرويسها | baseline start none → 2019-01-29; baseline finish none → 2019-02-04 |
| 68 | نصب توالت هاي شرقي | baseline start none → 2019-02-05; baseline finish none → 2019-02-06 |
| 69 | نصب سراميک سرويسها | baseline start none → 2019-02-07; baseline finish none → 2019-02-11 |
| 70 | **تاسيسات فاز دوم** | baseline start none → 2019-01-16; baseline finish none → 2019-02-28 |

| ID | Task | Other |
| --- | --- | --- |
| 71 | ساخت و نصب دريچه ها | baseline start none → 2019-02-09; baseline finish none → 2019-02-12 |
| 72 | نصب دستگاه چيلر | baseline start none → 2019-01-24; baseline finish none → 2019-01-26 |
| 73 | سيم کشي و کابل کشي | baseline start none → 2019-02-04; baseline finish none → 2019-02-12 |
| 74 | نصب کليد و پريز و ساير اقلام برقي | baseline start none → 2019-02-11; baseline finish none → 2019-02-14 |
| 75 | نصب چراغها | baseline start none → 2019-02-23; baseline finish none → 2019-02-23 |
| 76 | ساخت و نصب تابلوهاي برق | baseline start none → 2019-02-24; baseline finish none → 2019-02-28 |
| 77 | نصب سرويس هاي بهداشتي و شيرآلات | baseline start none → 2019-02-12; baseline finish none → 2019-02-13 |
| 78 | نصب آسانسور | baseline start none → 2019-01-16; baseline finish none → 2019-02-19 |
| 79 | **موتورخانه** | baseline start none → 2019-01-16; baseline finish none → 2019-02-17 |
| 80 | اجراي لوله کشي موتورخانه | baseline start none → 2019-01-16; baseline finish none → 2019-01-19 |
| 81 | نصب ديگها و مشعل پمپها | baseline start none → 2019-01-20; baseline finish none → 2019-01-21 |
| 82 | تست و راه اندازي و عايق کاري موتورخانه | baseline start none → 2019-02-13; baseline finish none → 2019-02-17 |
| 83 | **نقاشي** | baseline start none → 2019-02-02; baseline finish none → 2019-02-21 |
| 84 | اجراي کامل نقاشي سطوح گچي | baseline start none → 2019-02-02; baseline finish none → 2019-02-10 |
| 85 | اجراي کامل نقاشي سطوح فلزي | baseline start none → 2019-02-18; baseline finish none → 2019-02-20 |
| 86 | اجراي کامل نقاشي سطوح چوبي | baseline start none → 2019-02-18; baseline finish none → 2019-02-21 |
| 87 | **تميز کاري و تحويل و برچيدن کارگاه** | baseline start none → 2019-03-02; baseline finish none → 2019-03-14 |
| 88 | تميز کاري و تحويل و برچيدن کارگاه | baseline start none → 2019-03-02; baseline finish none → 2019-03-14 |
| 89 | پايان پروژه | baseline start none → 2019-03-14; baseline finish none → 2019-03-14 |
